Schedule from MS Project, 2017-10-16 to 2017-12-29, costs in zł.
Polsko-JapoÅ„ska Akedemia Technik Komputerowych

## Calendars

- Standard: Mon-Fri 08:00-12:00, 13:00-17:00; Sat-Sun off.

## Resources

| Resource | Rate |
| --- | --- |
| Programista | 120 |
| Projektant aplikacji | 140 |
| Administrator | 150 |
| Serwer | 5000 |
| Projektant baz danych | 140 |

## Schedule

| ID | WBS | Task | Duration | Start | Finish | Predecessors | Baseline start | Baseline finish | Baseline duration | Total slack | Free slack | Resources | Work | Cost | Baseline cost |
| --- | --- | --- | --- | --- | --- | --- | --- | --- | --- | --- | --- | --- | --- | --- | --- |
| 1 | 1 | Projektowanie aplikacji | 2w | 2017-10-16 | 2017-10-27 |  | 2017-10-16 | 2017-10-27 | 2w | 0d |  | Projektant aplikacji | 80h | 11,200 | 11,200 |
| 2 | 2 | Pisanie frontendu | 4w | 2017-10-30 | 2017-11-27 | 1 | 2017-10-30 | 2017-11-24 | 4w | 9d |  | Programista | 160h | 19,200 | 19,200 |
| 3 | 3 | **Projektowanie bazy danych** | 30d | 2017-10-30 | 2017-12-08 | 1 | 2017-10-30 | 2017-11-24 | 20d | 0d |  |  | 240h | 33,600 | 22,400 |
| 4 | 3.1 | Projektowanie bazy spelniajacej wymagania | 2w | 2017-10-30 | 2017-11-10 |  | 2017-10-30 | 2017-11-10 | 2w | 0d |  | Projektant baz danych | 80h | 11,200 | 11,200 |
| 5 | 3.2 | Optymalizacja bazy pod katem zapytan | 4w | 2017-11-13 | 2017-12-08 | 4 | 2017-11-13 | 2017-11-24 | 2w | 0d |  | Projektant baz danych | 160h | 22,400 | 11,200 |
| 6 | 4 | **Pisanie backendu** | 21d | 2017-10-30 | 2017-11-27 | 1 | 2017-10-30 | 2017-11-24 | 20d | 9d |  |  | 280h | 33,600 | 33,600 |
| 7 | 4.1 | Pisanie ETLi | 2w | 2017-10-30 | 2017-11-13 |  | 2017-10-30 | 2017-11-10 | 2w | 14d | 0d | Programista | 80h | 9,600 | 9,600 |
| 8 | 4.2 | Testowanie ETLi | 1w | 2017-11-14 | 2017-11-20 | 7 | 2017-11-13 | 2017-11-17 | 1w | 14d |  | Programista | 40h | 4,800 | 4,800 |
| 9 | 4.3 | Pisanie API | 3w | 2017-10-30 | 2017-11-20 |  | 2017-10-30 | 2017-11-17 | 3w | 9d | 0d | Programista | 120h | 14,400 | 14,400 |
| 10 | 4.4 | Testowanie API | 1w | 2017-11-21 | 2017-11-27 | 9 | 2017-11-20 | 2017-11-24 | 1w | 9d |  | Programista | 40h | 4,800 | 4,800 |
| 11 | 5 | Testy funkcjonalne aplikacji | 1w | 2017-12-11 | 2017-12-15 | 6, 2, 3 | 2017-11-27 | 2017-12-01 | 1w | 0d |  | Programista [200%] | 80h | 9,600 | 9,600 |
| 12 | 6 | Wdrozenie aplikacji na maszynie klienta | 2w | 2017-12-18 | 2017-12-29 | 11 | 2017-12-04 | 2017-12-15 | 2w | 0d |  | Administrator; Programista; Serwer; Projektant aplikacji | 240h | 37,800 | 37,800 |
